# VdS 3473 Einführung HQ und DE

Schedule from GanttProject, 2018-03-28 to 2018-06-04.
In diesem Projekt wird die Einführung der VdS 3473 für hartrodt organisiert.
Holidays every year on 01-01, 01-06, 05-01, 08-15, 10-03, 10-31, 11-01, 12-25, 12-26

## Calendars

- Project calendar: Mon-Fri working; Sat-Sun off. Exceptions (off unless hours are given): 2018-03-30 (Good Friday), 2018-04-02 (Easter Monday), 2018-05-10 (Ascension Day), 2018-05-21 (Whitmonday), 2018-05-31 (Corpus Christi (BW, BY, HE, NW, RP, SL, SN, TH)).

## Resources

| Resource | Group |
| --- | --- |
| Marina | Projektmanager |
| Nina (ISB) | ISB |
| Nina (BPM) | BPM |
| Kolja | IT-Verantwortlicher |
| Pascal | Datenschutzbeauftragter |
| AW | Topmanagement |
| JvT | Topmanagement |
| IST | IS Team |
| HR | HR |
| Björn |  |
| David |  |

## Schedule

| ID | WBS | Task | Duration | Start | Finish | Predecessors | Complete | Constraint | Resources |
| --- | --- | --- | --- | --- | --- | --- | --- | --- | --- |
| 1 | 1 | **Phase 0: inoffizielle Vorbereitungen** | 16d | 2018-03-28 | 2018-04-20 |  | 68% |  |  |
| 2 | 1.1 | Schulung VdS 3473 | 2d | 2018-03-28 | 2018-03-29 |  | 100% |  | Nina (ISB); Kolja |
| 3 | 1.2 | Nachbereitung des Lehrgangs; Stellenbeschreibung Nachbereitung des Lehrgangs; Stellenbeschreibung ISB | 5d | 2018-04-03 | 2018-04-09 | 2 | 100% |  | Nina (ISB) |
| 4 | 1.3 | Entwurf Projektplan | 4d | 2018-04-10 | 2018-04-13 | 3 | 100% |  | Nina (ISB) |
| 5 | 1.4 | **Glossar: 3473 Glossar ins IT Wiki** | 8d | 2018-04-11 | 2018-04-20 |  | 50% |  | Nina (ISB) |
| 6 | 1.4.1 | RfC: neues Topic im Glossary | 1d | 2018-04-11 | 2018-04-11 |  | 100% |  | Nina (ISB) |
| 7 | 1.4.2 | Entscheidung: Glossar auf DE oder EN hinterlegen? | 1d | 2018-04-18 | 2018-04-18 | 6 | 100% | start no earlier than 2018-04-18 | Kolja |
| 8 | 1.4.3 | Glossar (DE) ins IT Wiki | 1d | 2018-04-19 | 2018-04-19 | 6, 7 |  | start no earlier than 2018-04-19 | Björn |
| 9 | 1.4.4 | Glossar (EN) ins IT Wiki | 1d | 2018-04-20 | 2018-04-20 | 6, 7 |  | start no earlier than 2018-04-20 | Björn |
| 10 | 1.5 | Matrix vorbereiten (Kriterien // katastrophaler Schaden) -> für 9.2 | 1d | 2018-04-16 | 2018-04-16 |  |  |  | Nina (ISB) |
| 11 | 1.6 | zu erstellende Verfahren auflisten | 1d | 2018-04-17 | 2018-04-17 | 10 |  |  | Nina (ISB); Nina (BPM) |
| 12 | 1.7 | Verfahrensvorlage entwickeln gem. A1 | 1d | 2018-04-18 | 2018-04-18 | 11 |  |  | Nina (ISB) |
| 13 | 2 | **Phase 1: Anbahnung** | 13d | 2018-04-18 | 2018-05-07 | 11 | 1% |  |  |
| 14 | 2.1 | **Schritt 1: Voraussetzungen prüfen** | 2d | 2018-04-18 | 2018-04-19 |  |  |  |  |
| 15 | 2.1.1 | erschwerende Umstände für Projekt identifizieren | 1d | 2018-04-18 | 2018-04-18 | 3 |  |  | Marina |
| 16 | 2.1.2 | begünstigende Umstände für Projekt identifizieren | 1d | 2018-04-19 | 2018-04-19 | 3, 15 |  |  | Marina |
| 17 | 2.2 | **Schritt 2: Unterstützung erhalten** | 2d | 2018-04-20 | 2018-04-23 | 14 |  |  |  |
| 18 | 2.2.1 | inoffizielle Gespräche mit Unterstützern | 1d | 2018-04-20 | 2018-04-20 | 3 |  |  | Nina (ISB) |
| 19 | 2.2.2 | Meeting mit allen Unterstützern? | 1d | 2018-04-23 | 2018-04-23 | 18 |  |  | Nina (ISB) |
| 20 | 2.3 | **Schritt 3: Bestandsaufnahme durchführen** | 4d | 2018-04-24 | 2018-04-27 | 17 | 6% |  |  |
| 21 | 2.3.1 | **Erfüllungsgrad des Unternehmens feststellen (Quick Check)** | 1d | 2018-04-24 | 2018-04-24 |  | 33% |  | Nina (ISB) |
| 22 | 2.3.1.1 | Quick Check Nina | 1d | 2018-04-24 | 2018-04-24 |  | 100% |  | Nina (ISB) |
| 23 | 2.3.1.2 | Quick Check David (mit Nina) | 1d | 2018-04-24 | 2018-04-24 |  |  |  | Nina (ISB); David |
| 24 | 2.3.1.3 | Quick Check Kolja | 1d | 2018-04-24 | 2018-04-24 |  |  |  | Kolja |
| 25 | 2.3.2 | Übersetzung Begrifflichkeiten in Unternehmenssprache | 1d | 2018-04-25 | 2018-04-25 |  |  |  |  |
| 26 | 2.3.3 | Bestandsaufnahmen mit dem IT Verantwortlichen (=Quick Checks auswerten) | 1d | 2018-04-25 | 2018-04-25 | 22, 23, 24 |  |  | Nina (ISB); Kolja |
| 27 | 2.3.4 | schriftliche Dokumentation der Ergebnisse | 2d | 2018-04-26 | 2018-04-27 | 26 |  |  | Nina (ISB) |

| ID | WBS | Task | Type | Duration | Start | Finish | Predecessors | Resources |
| --- | --- | --- | --- | --- | --- | --- | --- | --- |
| 28 | 2.4 | **Schritt 4: Konzept erstellen (Meeting Kolja + Nina)** |  | 3d | 2018-04-30 | 2018-05-03 | 20 |  |
| 29 | 2.4.1 | Darstellung IST-Zustand (Summary zu Task 64) |  | 1d | 2018-04-30 | 2018-04-30 |  | Nina (ISB); Kolja |
| 30 | 2.4.2 | Definition globaler Ziele (s. Notes) |  | 1d | 2018-04-30 | 2018-04-30 |  | Nina (ISB); Kolja |
| 31 | 2.4.3 | Entwicklen der Maßnahmen |  | 1d | 2018-04-30 | 2018-04-30 |  | Nina (ISB); Kolja |
| 32 | 2.4.4 | Zeit- und Kostenschätzung |  | 1d | 2018-04-30 | 2018-04-30 |  | Nina (ISB); Kolja |
| 33 | 2.4.5 | Benennen von Metriken |  | 1d | 2018-04-30 | 2018-04-30 |  | Nina (ISB); Kolja |
| 34 | 2.4.6 | Konzept schreiben |  | 2d | 2018-05-02 | 2018-05-03 | 29, 30, 31, 32, 33 | Nina (ISB) |
| 35 | 2.5 | **Schritt 5: Beauftragung einholen** |  | 2d | 2018-05-04 | 2018-05-07 | 28 | Nina (ISB); Kolja |
| 36 | 2.5.1 | Beauftragung vorformulieren |  | 1d | 2018-05-04 | 2018-05-04 |  | Nina (ISB) |
| 37 | 2.5.2 | Konzept beim Topmanagement vorstellen |  | 1d | 2018-05-07 | 2018-05-07 | 36 | Nina (ISB) |
| 38 | 2.5.3 | schriftliche Beauftragung durch das Topmanagement | milestone | 0d | 2018-05-08 | 2018-05-08 | 37 | AW; JvT |
| 39 | 3 | **Phase 2: Vorbereitung des Unternehmens** |  | 2d | 2018-05-08 | 2018-05-09 | 13 |  |
| 40 | 3.1 | Projektmanagement (PM ernennen) |  | 1d | 2018-05-08 | 2018-05-08 |  |  |
| 41 | 3.2 | Kick-Off; eigentlicher Projektstart | milestone | 0d | 2018-05-09 | 2018-05-09 | 40 |  |
| 42 | 3.3 | Leitlinie, Richtlinien, Verfahren |  | 1d | 2018-05-09 | 2018-05-09 | 41 |  |
| 43 | 3.4 | Risikoanalyse und -behandlung |  | 1d | 2018-05-09 | 2018-05-09 | 41 |  |
| 44 | 3.5 | Kommunikation |  | 1d | 2018-05-09 | 2018-05-09 | 41 |  |
| 45 | 4 | **Phase 3: Durchführung** |  | 14d | 2018-05-11 | 2018-06-01 | 39 |  |
| 46 | 4.1 | **K4: Organisation der InfSicherheit** |  | 1d | 2018-05-15 | 2018-05-15 |  | AW; JvT |
| 47 | 4.1.1 | Informationssicherheitsbeauftragter: benennen; kommunizieren |  | 1d | 2018-05-15 | 2018-05-15 |  | AW; JvT |
| 48 | 4.1.2 | Informationssicherheitsteam: Mitglieder benennen |  | 1d | 2018-05-15 | 2018-05-15 |  |  |
| 49 | 4.1.3 | IT-Verantwortliche: evtl. weitere benennen außer ksa? |  | 1d | 2018-05-15 | 2018-05-15 |  |  |
| 50 | 4.1.4 | Administratoren: benennen, wer an InfSich arbeiten soll |  | 1d | 2018-05-15 | 2018-05-15 |  | Kolja |
| 51 | 4.1.5 | Vorg. mit Personalverantwortung: auflisten, ins Boot holen |  | 1d | 2018-05-15 | 2018-05-15 |  |  |
| 52 | 4.1.6 | Projektverantwortliche: Informationspflicht dem ISB ggü. klarmachen |  | 1d | 2018-05-15 | 2018-05-15 |  |  |

Notes:
- 30: 1. Schritt HQ / 2. Schritt DE / 3. Schritt Englische Version für alle
- 38: Dieser Meilenstein beendet die Anbahnungsphase

| ID | WBS | Task | Type | Duration | Start | Finish | Predecessors | Resources |
| --- | --- | --- | --- | --- | --- | --- | --- | --- |
| 53 | 4.2 | **K5: Leitlinie zur Informationssicherheit** |  | 4d | 2018-05-15 | 2018-05-18 |  | Nina (ISB); AW; JvT |
| 54 | 4.2.1 | Leitlinie entwerfen |  | 1d | 2018-05-15 | 2018-05-15 |  | Nina (ISB) |
| 55 | 4.2.2 | Leitlinie im Workshop festzurren |  | 1d | 2018-05-16 | 2018-05-16 | 54 | Nina (ISB); AW; JvT |
| 56 | 4.2.3 | Leitlinie final schreiben |  | 2d | 2018-05-17 | 2018-05-18 | 55 | Nina (ISB) |
| 57 | 4.2.4 | Leitlinie im Unternehmen kommunizieren | milestone | 0d | 2018-05-22 | 2018-05-22 | 56 | AW; JvT |
| 58 | 4.3 | **K6: Richtlinien zur Informationssicherheit** |  | 8d | 2018-05-22 | 2018-06-01 | 53 | Nina (ISB) |
| 59 | 4.3.1 | Richtlinienentwurf zum Dranlanghangeln erstellen |  | 1d | 2018-05-22 | 2018-05-22 |  | Nina (ISB) |
| 60 | 4.3.2 | **Richtlinie Generelle Nutzungsbedigungen** |  | 4d | 2018-05-23 | 2018-05-28 | 59 | Nina (ISB) |
| 61 | 4.3.2.1 | Workshop zur Richtlinie "generelle Nutzung" |  | 1d | 2018-05-23 | 2018-05-23 |  | Nina (ISB); IST |
| 62 | 4.3.2.2 | Richtlinie "generelle Nutzung" schreiben |  | 2d | 2018-05-24 | 2018-05-25 | 61 | Nina (ISB) |
| 63 | 4.3.2.3 | Richtlinie "generelle Nutzung" abstimmen |  | 1d | 2018-05-28 | 2018-05-28 | 62 | Nina (ISB); IST |
| 64 | 4.3.2.4 | Richtlinie "generelle Nutzung" VÖ | milestone | 0d | 2018-05-29 | 2018-05-29 | 63 | AW |
| 65 | 4.3.3 | **Richtlinie Grundlegende Verhaltensregeln** |  | 4d | 2018-05-23 | 2018-05-28 | 59 | Nina (ISB) |
| 66 | 4.3.3.1 | Workshop zur Richtlinie "grundlegende Verhaltensregeln" |  | 1d | 2018-05-23 | 2018-05-23 |  | Nina (ISB); IST |
| 67 | 4.3.3.2 | Richtlinie "grundlegende Verhaltensregeln" schreiben |  | 2d | 2018-05-24 | 2018-05-25 | 66 | Nina (ISB) |
| 68 | 4.3.3.3 | Richtlinie "grundlegende Verhaltensregeln" abstimmen |  | 1d | 2018-05-28 | 2018-05-28 | 67 | Nina (ISB); IST |
| 69 | 4.3.3.4 | Richtlinie "grundlegende Verhaltensregeln" VÖ | milestone | 0d | 2018-05-29 | 2018-05-29 | 68 | AW |
| 70 | 4.3.4 | **Richtlinie Informationsfluss bei Abwesenheit** |  | 4d | 2018-05-23 | 2018-05-28 | 59 | Nina (ISB) |
| 71 | 4.3.4.1 | Workshop zur Richtlinie "Infofluss Abwesenheit" |  | 1d | 2018-05-23 | 2018-05-23 |  | Nina (ISB); IST |
| 72 | 4.3.4.2 | Richtlinie "Infofluss Abwesenheit" schreiben |  | 2d | 2018-05-24 | 2018-05-25 | 71 | Nina (ISB) |
| 73 | 4.3.4.3 | Richtlinie "Infofluss Abwesenheit" abstimmen |  | 1d | 2018-05-28 | 2018-05-28 | 72 | Nina (ISB); IST |
| 74 | 4.3.4.4 | Richtlinie "Infofluss Abwesenheit" VÖ | milestone | 0d | 2018-05-29 | 2018-05-29 | 73 | AW |
| 75 | 4.3.5 | **Richtlinie Privatnutzung** |  | 4d | 2018-05-23 | 2018-05-28 | 59 | Nina (ISB) |
| 76 | 4.3.5.1 | Workshop zur Richtlinie "Privatnutzung" |  | 1d | 2018-05-23 | 2018-05-23 |  | Nina (ISB); IST |
| 77 | 4.3.5.2 | Richtlinie "Privatnutzung" schreiben |  | 2d | 2018-05-24 | 2018-05-25 | 76 | Nina (ISB) |
| 78 | 4.3.5.3 | Richtlinie "Privatnutzung" abstimmen |  | 1d | 2018-05-28 | 2018-05-28 | 77 | Nina (ISB); IST |
| 79 | 4.3.5.4 | Richtlinie "Privatnutzung" VÖ | milestone | 0d | 2018-05-29 | 2018-05-29 | 78 | AW |

| ID | WBS | Task | Type | Duration | Start | Finish | Predecessors | Resources |
| --- | --- | --- | --- | --- | --- | --- | --- | --- |
| 80 | 4.3.6 | **Richtlinie "Mobile IT-Systeme"** |  | 4d | 2018-05-23 | 2018-05-28 | 59 | Nina (ISB) |
| 81 | 4.3.6.1 | Workshop zur Richtlinie "Mobile IT-Systeme" |  | 1d | 2018-05-23 | 2018-05-23 |  | Nina (ISB); IST |
| 82 | 4.3.6.2 | Richtlinie "Mobile IT-Systeme" schreiben |  | 2d | 2018-05-24 | 2018-05-25 | 81 | Nina (ISB) |
| 83 | 4.3.6.3 | Richtlinie "Mobile IT-Systeme" abstimmen |  | 1d | 2018-05-28 | 2018-05-28 | 82 | Nina (ISB); IST |
| 84 | 4.3.6.4 | Richtlinie "Mobile IT-Systeme" VÖ | milestone | 0d | 2018-05-29 | 2018-05-29 | 83 | AW |
| 85 | 4.3.7 | **Richtlinie Missbrauchskontrolle** |  | 4d | 2018-05-23 | 2018-05-28 | 59 | Nina (ISB) |
| 86 | 4.3.7.1 | Workshop zur Richtlinie "Missbrauchskontrolle" |  | 1d | 2018-05-23 | 2018-05-23 |  | Nina (ISB); IST |
| 87 | 4.3.7.2 | Richtlinie "Missbrauchskontrolle" schreiben |  | 2d | 2018-05-24 | 2018-05-25 | 86 | Nina (ISB) |
| 88 | 4.3.7.3 | Richtlinie "Missbrauchskontrolle" abstimmen |  | 1d | 2018-05-28 | 2018-05-28 | 87 | Nina (ISB); IST |
| 89 | 4.3.7.4 | Richtlinie "Missbrauchskontrolle" VÖ | milestone | 0d | 2018-05-29 | 2018-05-29 | 88 | AW |
| 90 | 4.3.8 | **Richtlinie Mobile Datenträger** |  | 4d | 2018-05-23 | 2018-05-28 | 59 | Nina (ISB) |
| 91 | 4.3.8.1 | Workshop zur Richtlinie "mobile Datenträger" |  | 1d | 2018-05-23 | 2018-05-23 |  | Nina (ISB); IST |
| 92 | 4.3.8.2 | Richtlinie "mobile Datenträger" schreiben |  | 2d | 2018-05-24 | 2018-05-25 | 91 | Nina (ISB) |
| 93 | 4.3.8.3 | Richtlinie "mobile Datenträger" abstimmen |  | 1d | 2018-05-28 | 2018-05-28 | 92 | Nina (ISB); IST |
| 94 | 4.3.8.4 | Richtlinie "mobile Datenträger" VÖ | milestone | 0d | 2018-05-29 | 2018-05-29 | 93 | AW |
| 95 | 4.3.9 | **Richtlinie Datensicherung** |  | 4d | 2018-05-23 | 2018-05-28 | 59 | Nina (ISB) |
| 96 | 4.3.9.1 | Workshop zur Richtlinie "Datensicherung" |  | 1d | 2018-05-23 | 2018-05-23 |  | Nina (ISB); IST |
| 97 | 4.3.9.2 | Richtlinie "Datensicherung" schreiben |  | 2d | 2018-05-24 | 2018-05-25 | 96 | Nina (ISB) |
| 98 | 4.3.9.3 | Richtlinie "Datensicherung" abstimmen |  | 1d | 2018-05-28 | 2018-05-28 | 97 | Nina (ISB); IST |
| 99 | 4.3.9.4 | Richtlinie "Datensicherung" VÖ | milestone | 0d | 2018-05-29 | 2018-05-29 | 98 | AW |
| 100 | 4.3.10 | **Richtlinie "Störungen und Ausfälle"** |  | 4d | 2018-05-23 | 2018-05-28 | 59 | Nina (ISB) |
| 101 | 4.3.10.1 | Workshop zur Richtlinie "Störungen und Ausfälle" |  | 1d | 2018-05-23 | 2018-05-23 |  | Nina (ISB); IST |
| 102 | 4.3.10.2 | Richtlinie "Störungen und Ausfälle" schreiben |  | 2d | 2018-05-24 | 2018-05-25 | 101 | Nina (ISB) |
| 103 | 4.3.10.3 | Richtlinie "Störungen und Ausfälle" abstimmen |  | 1d | 2018-05-28 | 2018-05-28 | 102 | Nina (ISB); IST |
| 104 | 4.3.10.4 | Richtlinie "Störungen und Ausfälle" VÖ | milestone | 0d | 2018-05-29 | 2018-05-29 | 103 | AW |

| ID | WBS | Task | Type | Duration | Start | Finish | Predecessors | Complete | Resources |
| --- | --- | --- | --- | --- | --- | --- | --- | --- | --- |
| 105 | 4.3.11 | **Richtlinie "Sicherheitsvorfälle"** |  | 4d | 2018-05-23 | 2018-05-28 | 59 |  | Nina (ISB) |
| 106 | 4.3.11.1 | Workshop zur Richtlinie "Sicherheitsvorfälle" |  | 1d | 2018-05-23 | 2018-05-23 |  |  | Nina (ISB); IST |
| 107 | 4.3.11.2 | Richtlinie "Sicherheitsvorfälle" schreiben |  | 2d | 2018-05-24 | 2018-05-25 | 106 |  | Nina (ISB) |
| 108 | 4.3.11.3 | Richtlinie "Sicherheitsvorfälle" abstimmen |  | 1d | 2018-05-28 | 2018-05-28 | 107 |  | Nina (ISB); IST |
| 109 | 4.3.11.4 | Richtlinie "Sicherheitsvorfälle" VÖ | milestone | 0d | 2018-05-29 | 2018-05-29 | 108 |  | AW |
| 110 | 4.3.12 | **Richtlinie für Externe (alles in einem gemäß K6.4)** |  | 7d | 2018-05-23 | 2018-06-01 | 59 |  | Nina (ISB) |
| 111 | 4.3.12.1 | Workshop zur Richtlinie für Externe |  | 1d | 2018-05-23 | 2018-05-23 |  |  | Nina (ISB); IST |
| 112 | 4.3.12.2 | Richtlinie für Externe schreiben |  | 5d | 2018-05-24 | 2018-05-30 | 111 |  | Nina (ISB) |
| 113 | 4.3.12.3 | Richtlinie für Externe abstimmen |  | 1d | 2018-06-01 | 2018-06-01 | 112 |  | Nina (ISB); IST |
| 114 | 4.3.12.4 | Richtlinie für Externe VÖ | milestone | 0d | 2018-06-04 | 2018-06-04 | 113 |  | AW |
| 115 | 4.4 | **K7: Personal** |  | 1d | 2018-05-15 | 2018-05-15 |  |  | AW; JvT; HR |
| 116 | 4.4.1 | Verfahren "vor der Einstellung" anpassen |  | 1d | 2018-05-15 | 2018-05-15 |  |  | HR |
| 117 | 4.4.2 | Verfahren für die Einstellung |  | 1d | 2018-05-15 | 2018-05-15 |  |  | HR |
| 118 | 4.4.3 | Verfahren für den Wechsel der Anstellung |  | 1d | 2018-05-15 | 2018-05-15 |  |  | HR |
| 119 | 4.4.4 | Verfahren für die Beendigung der Anstellung |  | 1d | 2018-05-15 | 2018-05-15 |  |  | HR |
| 120 | 4.5 | **K8: Wissen** |  | 10d | 2018-05-15 | 2018-05-29 |  | 3% | Nina (ISB) |
| 121 | 4.5.1 | **Verfahren: Infos über Änderungen bzgl. InfoSich** |  | 2d | 2018-05-15 | 2018-05-16 |  | 20% | Nina (ISB) |
| 122 | 4.5.1.1 | Informationsquellen sammeln (ct, BSI auf twitter, Heise...) |  | 1d | 2018-05-15 | 2018-05-15 |  | 100% | Nina (ISB) |
| 123 | 4.5.1.2 | Prozess erstellen (Informationsquellen bedenken) |  | 2d | 2018-05-15 | 2018-05-16 |  |  | Nina (ISB) |
| 124 | 4.5.1.3 | Infomatrix (Wer? wie informieren?) entwickeln |  | 1d | 2018-05-15 | 2018-05-15 |  |  | Nina (ISB) |
| 125 | 4.5.1.4 | Softwarehersteller fragen: Wie werden wir informiert? |  | 1d | 2018-05-15 | 2018-05-15 |  |  | Kolja |
| 126 | 4.5.2 | **Verfahren: Sensibilisierung, Aus- und Weiterbildung** |  | 10d | 2018-05-15 | 2018-05-29 |  |  | Nina (ISB) |
| 127 | 4.5.2.1 | Training zu Gefährdungen und Umgang mit Sicherheitsmaßnahmen (zielgruppenorientiert) |  | 1d | 2018-05-15 | 2018-05-15 |  |  | Nina (ISB) |
| 128 | 4.5.2.2 | Training zur InfoSich Leitlinie entwickeln |  | 1d | 2018-05-22 | 2018-05-22 | 56 |  | Nina (ISB) |
| 129 | 4.5.2.3 | Trainings (E-Learning?) zu den InfoSich Richtlinien |  | 1d | 2018-05-29 | 2018-05-29 | 1, 63, 68, 73, 78, 83, 88, 93, 98, 103, 108 |  | Nina (ISB) |
| 130 | 4.5.2.4 | Konsequenzen bei Zuwiderhandlungen schulen! |  | 1d | 2018-05-15 | 2018-05-15 |  |  | Nina (ISB) |
| 131 | 4.5.3 | Protokollieren, wer welches Training absolviert hat. Wiederholungstermine. |  | 1d | 2018-05-15 | 2018-05-15 |  |  | HR |

| ID | WBS | Task | Type | Duration | Start | Finish | Predecessors | Resources |
| --- | --- | --- | --- | --- | --- | --- | --- | --- |
| 132 | 4.6 | **K9: hochkritische IT Ressourcen** |  | 7d | 2018-05-15 | 2018-05-24 |  | Nina (ISB) |
| 133 | 4.6.1 | Verfahren implementieren? Oder BIA nach BSI oder DIN? |  | 1d | 2018-05-15 | 2018-05-15 |  | Nina (ISB); Kolja |
| 134 | 4.6.2 | **9.1 zentrale Geschäftsprozesse** |  | 3d | 2018-05-15 | 2018-05-17 |  | AW; JvT |
| 135 | 4.6.2.1 | zentrale Geschäftsprozesse identifizieren |  | 1d | 2018-05-15 | 2018-05-15 |  | Nina (ISB); AW; JvT |
| 136 | 4.6.2.2 | Process Owner für zentrale Geschäftsprozesse ermitteln |  | 1d | 2018-05-16 | 2018-05-16 | 135 | Nina (ISB); AW; JvT |
| 137 | 4.6.2.3 | Prozessdokumentation Prozess #1 |  | 1d | 2018-05-17 | 2018-05-17 | 136 |  |
| 138 | 4.6.2.4 | Prozessdokumentation Prozess #2 |  | 1d | 2018-05-17 | 2018-05-17 | 136 |  |
| 139 | 4.6.2.5 | Prozessdokumentation Prozess #3 |  | 1d | 2018-05-17 | 2018-05-17 | 136 |  |
| 140 | 4.6.2.6 | Freigabe Prozessdoku | milestone | 0d | 2018-05-18 | 2018-05-18 | 137 | AW; JvT |
| 141 | 4.6.3 | **9.2 hochkritische Informationen ermitteln (mit Process Ownern)** |  | 3d | 2018-05-18 | 2018-05-23 | 134 | Nina (ISB) |
| 142 | 4.6.3.1 | Workshop hochkritische Informationen Prozess #1 |  | 1d | 2018-05-18 | 2018-05-18 | 10 | Nina (ISB) |
| 143 | 4.6.3.2 | Workshop hochkritische Informationen Prozess #2 |  | 1d | 2018-05-22 | 2018-05-22 | 142 | Nina (ISB) |
| 144 | 4.6.3.3 | Workshop hochkritische Informationen Prozess #3 |  | 1d | 2018-05-23 | 2018-05-23 | 143 | Nina (ISB) |
| 145 | 4.6.4 | **9.3 hochkritische IT-Systeme etc.** |  | 1d | 2018-05-24 | 2018-05-24 | 141 |  |
| 146 | 4.6.4.1 | Workshop hochkritische IT |  | 1d | 2018-05-24 | 2018-05-24 |  | Nina (ISB); Kolja |
| 147 | 4.6.5 | 9.4 Individualsoftware |  | 1d | 2018-05-24 | 2018-05-24 | 145SS |  |
| 148 | 4.7 | **K10: IT-Systeme** |  | 10d | 2018-05-11 | 2018-05-25 |  | Kolja |
| 149 | 4.7.1 | 10.1 Inventarisierung (muss nur geprüft werden) |  | 1d | 2018-05-15 | 2018-05-15 |  | Kolja |
| 150 | 4.7.2 | **10.2 Lebenszyklus** |  | 1d | 2018-05-15 | 2018-05-15 |  | Kolja |
| 151 | 4.7.2.1 | 10.2.1 Verfahren Inbetriebnahme u. Änderung |  | 1d | 2018-05-15 | 2018-05-15 |  | Nina (BPM) |
| 152 | 4.7.2.2 | 10.2.2 Verfahren Ausmusterung u. Weiterverwendung |  | 1d | 2018-05-15 | 2018-05-15 |  | Nina (BPM) |
| 153 | 4.7.3 | **10.3 Basisschutz für ALLE IT-Systeme implementieren** |  | 4d | 2018-05-15 | 2018-05-18 |  | Kolja |
| 154 | 4.7.3.1 | Liste aller IT-Systeme generieren |  | 1d | 2018-05-15 | 2018-05-15 |  | Kolja |
| 155 | 4.7.3.2 | Matrix zum Basisschutz erstellen (alls Systeme // alle Anforderungen) |  | 2d | 2018-05-16 | 2018-05-17 | 154 | Nina (ISB) |
| 156 | 4.7.3.3 | 10.3.1 Updates |  | 1d | 2018-05-18 | 2018-05-18 | 155 | Kolja |
| 157 | 4.7.3.4 | 10.3.2 Beschränkung des Netzwerkverkehrs |  | 1d | 2018-05-18 | 2018-05-18 | 155 | Kolja |
| 158 | 4.7.3.5 | 10.3.3 Protokollierung |  | 1d | 2018-05-18 | 2018-05-18 | 155 | Kolja |
| 159 | 4.7.3.6 | (10.3.4 ext. Schnittstellen u Laufwerke) -> SOLLTE |  | 1d | 2018-05-18 | 2018-05-18 | 155 |  |
| 160 | 4.7.3.7 | 10.3.5 Schadsoftware |  | 1d | 2018-05-18 | 2018-05-18 | 155 | Kolja |
| 161 | 4.7.3.8 | 10.3.6 starten von fremden Medien |  | 1d | 2018-05-18 | 2018-05-18 | 155 | Kolja |
| 162 | 4.7.3.9 | 10.3.7 Authentifizierung |  | 1d | 2018-05-18 | 2018-05-18 | 155 | Kolja |
| 163 | 4.7.3.10 | 10.3.8 Zugriffsbeschränkungen |  | 1d | 2018-05-18 | 2018-05-18 | 155 | Kolja |

| ID | WBS | Task | Duration | Start | Finish | Predecessors | Resources |
| --- | --- | --- | --- | --- | --- | --- | --- |
| 164 | 4.7.4 | **10.4 mobile IT Systeme** | 3d | 2018-05-11 | 2018-05-15 |  | Kolja |
| 165 | 4.7.4.1 | 10.4.3 Verfahren zum Verlust | 1d | 2018-05-11 | 2018-05-11 | 11, 12 | Kolja |
| 166 | 4.7.4.2 | 10.4.2 Schutz der Informationen | 1d | 2018-05-15 | 2018-05-15 |  | Kolja |
| 167 | 4.7.5 | **10.5 zusätzl. Maßnahmen für hochkritische IT Systeme** | 1d | 2018-05-25 | 2018-05-25 | 146 | Kolja |
| 168 | 4.7.5.1 | 10.5.1 Risikoanalyse | 1d | 2018-05-25 | 2018-05-25 |  | Kolja |
| 169 | 4.7.5.2 | 10.5.2 Notbetriebsniveau | 1d | 2018-05-25 | 2018-05-25 |  | Kolja |
| 170 | 4.7.5.3 | 10.5.3 Robustheit | 1d | 2018-05-25 | 2018-05-25 |  | Kolja |
| 171 | 4.7.5.4 | 10.5.4 externe Schnittstellen und Laufwerke | 1d | 2018-05-25 | 2018-05-25 |  | Kolja |
| 172 | 4.7.5.5 | 10.5.5 Änderungsmanagement | 1d | 2018-05-25 | 2018-05-25 |  | Kolja |
| 173 | 4.7.5.6 | 10.5.6 Dokumentation | 1d | 2018-05-25 | 2018-05-25 |  | Kolja |
| 174 | 4.7.5.7 | 10.5.7 Datensicherung | 1d | 2018-05-25 | 2018-05-25 |  | Kolja |
| 175 | 4.7.5.8 | 10.5.8 Überwachung | 1d | 2018-05-25 | 2018-05-25 |  | Kolja |
| 176 | 4.7.5.9 | 10.5.9 Ersatzsysteme und -verfahren | 1d | 2018-05-25 | 2018-05-25 |  | Kolja |
| 177 | 4.7.5.10 | 10.5.10 kritische Individualsoftware | 1d | 2018-05-25 | 2018-05-25 | 147 | Kolja |
| 178 | 4.8 | **K11: Netzwerke und Verbindungen** | 1d | 2018-05-15 | 2018-05-15 |  | Kolja |
| 179 | 4.8.1 | 11.1 Netzwerkplan | 1d | 2018-05-15 | 2018-05-15 |  | Kolja |
| 180 | 4.8.2 | 11.2 aktive Netzwerkkomponenten | 1d | 2018-05-15 | 2018-05-15 |  | Kolja |
| 181 | 4.8.3 | 11.3 Netzübergänge | 1d | 2018-05-15 | 2018-05-15 |  | Kolja |
| 182 | 4.8.4 | **11.4 Basisschutz Netzwerke** | 1d | 2018-05-15 | 2018-05-15 |  | Kolja |
| 183 | 4.8.4.1 | 11.4.1 Netzwerkanschlüsse | 1d | 2018-05-15 | 2018-05-15 |  | Kolja |
| 184 | 4.8.4.2 | 11.4.2 Segmentierung | 1d | 2018-05-15 | 2018-05-15 |  | Kolja |
| 185 | 4.8.4.3 | 11.4.3 Fernzugriff | 1d | 2018-05-15 | 2018-05-15 |  | Kolja |
| 186 | 4.8.4.4 | 11.4.4 Netzwerkkopplung | 1d | 2018-05-15 | 2018-05-15 |  | Kolja |
| 187 | 4.8.5 | 11.5 zus. Maßnahmen für hochkritische Verbindungen | 1d | 2018-05-15 | 2018-05-15 |  | Kolja |
| 188 | 4.9 | K13: Umgebung (Absicherung gegen Umwelteinflüsse) | 1d | 2018-05-15 | 2018-05-15 |  | Kolja |

| ID | WBS | Task | Type | Duration | Start | Finish | Predecessors | Resources |
| --- | --- | --- | --- | --- | --- | --- | --- | --- |
| 189 | 4.10 | **K14: IT-Outsourcing und Cloud Computing** |  | 1d | 2018-05-15 | 2018-05-15 |  | Kolja |
| 190 | 4.10.1 | K14.2 Vertragsgestaltung -> vorhandene Verträge prüfen |  | 1d | 2018-05-15 | 2018-05-15 |  | Kolja |
| 191 | 4.11 | **K15: Zugänge und Zugriffsrechte** |  | 2d | 2018-05-15 | 2018-05-16 |  | Kolja |
| 192 | 4.11.1 | New User prüfen (Adminuser MUSS Kolja genehmigen) |  | 1d | 2018-05-15 | 2018-05-15 |  | Nina (BPM) |
| 193 | 4.11.2 | User Cancellation prüfen (wer muss informiert werden?) |  | 1d | 2018-05-15 | 2018-05-15 |  | Nina (BPM) |
| 194 | 4.11.3 | User Change prüfen |  | 1d | 2018-05-15 | 2018-05-15 |  | Nina (BPM) |
| 195 | 4.11.4 | neue User-Prozesse abstimmen |  | 1d | 2018-05-16 | 2018-05-16 | 192, 193, 194 | Nina (BPM); Kolja |
| 196 | 4.12 | **K16: Datensicherung und Archivierung** |  | 4d | 2018-05-15 | 2018-05-18 |  | Kolja |
| 197 | 4.12.1 | 16.2 Vorgaben für Archivierung (@Kolja: Wer soll das liefern?) |  | 1d | 2018-05-15 | 2018-05-15 |  | Kolja |
| 198 | 4.12.2 | **16.3 DaSi Verfahren (siehe Kommentierung zur VdS 3473)** |  | 2d | 2018-05-15 | 2018-05-16 |  | Kolja |
| 199 | 4.12.2.1 | Verfahren Datensicherung |  | 1d | 2018-05-15 | 2018-05-15 |  | Kolja |
| 200 | 4.12.2.2 | Verfahren Datenwiederherstellung |  | 1d | 2018-05-16 | 2018-05-16 | 199 | Kolja |
| 201 | 4.12.2.3 | Verfahren Datenarchivierung |  | 1d | 2018-05-16 | 2018-05-16 | 197 | Kolja |
| 202 | 4.12.3 | 16.5 Basischutz DaSi |  | 1d | 2018-05-17 | 2018-05-17 | 198 | Kolja |
| 203 | 4.12.4 | 16.6 zusätzliche Maßnahmen für hochkritische IT-Systeme |  | 1d | 2018-05-18 | 2018-05-18 | 202 | Kolja |
| 204 | 4.13 | **K17: Störungen und Ausfälle** |  | 3d | 2018-05-15 | 2018-05-17 |  | Nina (ISB) |
| 205 | 4.13.1 | Begrifflichkeiten definieren (ist jeder Defect eine Störung?) |  | 1d | 2018-05-15 | 2018-05-15 |  | Nina (ISB) |
| 206 | 4.13.2 | 17.2 Reaktion -> Handling customer requests Prozess prüfen |  | 1d | 2018-05-16 | 2018-05-16 | 205 | Nina (ISB) |
| 207 | 4.13.3 | 17.2 Reaktion -> Nachbereitung etablieren! |  | 1d | 2018-05-17 | 2018-05-17 | 205, 206 | Nina (ISB) |
| 208 | 4.14 | K18: Sicherheitsvorfälle |  | 1d | 2018-05-16 | 2018-05-16 | 205 | Nina (ISB) |
| 209 | 5 | Projektabschluss | milestone | 0d | 2018-06-04 | 2018-06-04 | 45 |  |
| 210 | 6 | Phase 4: Überführen in den Betrieb |  | 1d | 2018-06-04 | 2018-06-04 | 209 |  |
