# Leesburg Turnpike WRF Dewatering Improvements

Schedule from GanttProject, 2018-03-05 to 2018-12-05.

## Calendars

- Project calendar: Mon-Thu working; Fri-Sun off.

## Schedule

| ID | WBS | Task | Type | Duration | Start | Finish | Predecessors | Constraint |
| --- | --- | --- | --- | --- | --- | --- | --- | --- |
| 1 | 1 | **Admin and Prelim Sitework** |  | 31d | 2018-03-05 | 2018-04-25 |  |  |
| 2 | 1.1 | NOTICE TO PROCEED | milestone | 0d | 2018-03-05 | 2018-03-05 |  |  |
| 3 | 1.2 | Permits and Procurement |  | 20d | 2018-03-05 | 2018-04-05 | 2SS |  |
| 4 | 1.3 | Survey and Layout- Pre Clearing |  | 1d | 2018-04-09 | 2018-04-09 | 3 |  |
| 5 | 1.4 | Mobilization |  | 2d | 2018-04-10 | 2018-04-11 | 4 |  |
| 6 | 1.5 | Clearing and Grubbing |  | 4d | 2018-04-12 | 2018-04-18 | 5 |  |
| 7 | 1.6 | Silt Fence and Tree Protection |  | 4d | 2018-04-19 | 2018-04-25 | 6 |  |
| 8 | 1.7 | Survey and Layout- Post Clearing |  | 1d | 2018-04-19 | 2018-04-19 | 6 |  |
| 9 | 2 | **Yard Piping and Mechanical** |  | 91d | 2018-04-23 | 2018-09-26 | 8 |  |
| 10 | 2.1 | Install Compressed Air Lines |  | 1d | 2018-04-23 | 2018-04-23 |  |  |
| 11 | 2.2 | Demo Concrete Valley Gutter |  | 2d | 2018-04-23 | 2018-04-24 |  |  |
| 12 | 2.3 | Tie in Building Downspouts |  | 2d | 2018-09-19 | 2018-09-20 | 25 |  |
| 13 | 2.4 | 15" ABS Pipe Encasement |  | 3d | 2018-09-24 | 2018-09-26 | 12 |  |
| 14 | 2.5 | 3" Potable Water line |  | 3d | 2018-04-23 | 2018-04-25 |  |  |
| 15 | 2.6 | 6" Digested Sludge Line |  | 4d | 2018-04-23 | 2018-04-26 |  |  |
| 16 | 2.7 | 3" Reclaimed Water Line |  | 3d | 2018-04-23 | 2018-04-25 |  |  |
| 17 | 2.8 | 8" & 10" DR pipe |  | 4d | 2018-04-23 | 2018-04-26 |  |  |
| 18 | 3 | Flatwork prep |  | 4d | 2018-04-25 | 2018-05-01 |  |  |
| 19 | 4 | **Site Prep for Metal Building** |  | 12d | 2018-04-23 | 2018-05-10 |  |  |
| 20 | 4.1 | Footings and Rebar |  | 8d | 2018-04-23 | 2018-05-03 | 8 |  |
| 21 | 4.2 | Underslab Utilities |  | 4d | 2018-05-07 | 2018-05-10 | 20 |  |
| 22 | 4.3 | Trench Drains and Precast Sumps |  | 4d | 2018-05-07 | 2018-05-10 | 20 |  |
| 23 | 5 | Concrete for Metal Building |  | 8d | 2018-05-14 | 2018-05-24 | 21 |  |
| 24 | 6 | Install Belt Press, Process Equipment & Accessories |  | 6d | 2018-08-27 | 2018-09-04 | 23, 36 |  |
| 25 | 7 | Install Metal Building |  | 8d | 2018-09-05 | 2018-09-18 | 24 |  |
| 26 | 8 | Flatwork Concrete |  | 4d | 2018-09-19 | 2018-09-25 | 25 |  |
| 27 | 9 | Install Building lighting and Elec |  | 8d | 2018-09-19 | 2018-10-02 | 25 |  |
| 28 | 10 | Install Process Piping |  | 8d | 2018-09-19 | 2018-10-02 | 25 |  |
| 29 | 11 | Install Misc. Metals and Platforms |  | 4d | 2018-10-03 | 2018-10-09 | 28 |  |
| 30 | 12 | Equipment Startup |  | 12d | 2018-10-10 | 2018-10-30 | 29 |  |
| 31 | 13 | Demobilization |  | 1d | 2018-10-31 | 2018-10-31 | 30 |  |
| 32 | 14 | Substantial Completion | milestone | 0d | 2018-11-05 | 2018-11-05 | 31 | start no earlier than 2018-11-05 |
| 33 | 15 | Final Completion | milestone | 0d | 2018-12-05 | 2018-12-05 | 31 | start no earlier than 2018-12-05 |

| ID | WBS | Task | Duration | Start | Finish | Predecessors |
| --- | --- | --- | --- | --- | --- | --- |
| 34 | 16 | **Lead Times** | 114d | 2018-03-05 | 2018-09-18 |  |
| 35 | 16.1 | Filter Press Submittals | 20d | 2018-03-05 | 2018-04-05 | 2 |
| 36 | 16.2 | Filter Press | 80d | 2018-04-09 | 2018-08-23 | 35 |
| 37 | 16.3 | Metal Building | 40d | 2018-06-27 | 2018-09-04 | 25SF |
| 38 | 16.4 | Seepex Sludge Pumps | 40d | 2018-07-11 | 2018-09-18 | 28SF |
| 39 | 16.5 | Barney's Submersible Plumps | 40d | 2018-07-11 | 2018-09-18 | 28SF |
