# Positionierung & Marketingauftritt Zehetbauer&Sendlbeck

Schedule from GanttProject, 2017-05-10 to 2017-08-09.
C&T Huhn
Das Gesamtpaket Positionierung & Marketingauftritt umfasst im Wesentlichen die folgendne Inhalte: / • Entwicklung einer Positionierung im Markt / • Logoentwicklung und -umsetzung / • Erstellung eines Styleguides, indem die für das Dentallabor relevanten Designelemente und der Umgang mit diesen festgelegt ist / • Konzeption und Umsetzung einer dynamischen Internetpräsenz inkl. Textleistungen / • Erstellung einer Facebook Fanpage für die Zielgruppe der jungen Zahnärzte / • Erstellung von Maxipostkarten zur Vertriebsunterstützung
Holidays every year on 01-01, 01-06, 05-01, 08-15, 10-03, 10-31, 11-01, 12-25, 12-26

## Calendars

- Project calendar: Mon-Fri working; Sat-Sun off. Exceptions (off unless hours are given): 2017-05-25 (Ascension Day), 2017-06-05 (Whitmonday), 2017-06-15 (Corpus Christi (BW, BY, HE, NW, RP, SL, SN, TH)).

## Resources

| Resource | Group |
| --- | --- |
| Nina Sachs | Projektmanager (C&T Huhn) |
| Karin Janwlecke | Grafikdesign |
| Thorsten Huhn | Projektmanager (C&T Huhn) |
| Patrick Redlich | Projektmanager (Z&S) |
| Thomas Zehetbauer | Projektmanager (Z&S) |

## Schedule

| ID | WBS | Task | Type | Duration | Start | Finish | Predecessors | Constraint | Resources |
| --- | --- | --- | --- | --- | --- | --- | --- | --- | --- |
| 1 | 1 | Positinierungsworkshop | milestone | 0d | 2017-05-10 | 2017-05-10 |  |  | Nina Sachs; Thorsten Huhn; Patrick Redlich; Thomas Zehetbauer |
| 2 | 2 | Erarbeiten Unternehmensmission |  | 5d | 2017-05-10 | 2017-05-16 | 1 |  | Nina Sachs; Thorsten Huhn; Patrick Redlich; Thomas Zehetbauer |
| 3 | 3 | Vorschläge Farben, Schriften und Templates |  | 7d | 2017-05-10 | 2017-05-18 | 1 |  | Nina Sachs; Karin Janwlecke; Thorsten Huhn |
| 4 | 4 | Entscheidung 1 | milestone | 0d | 2017-05-29 | 2017-05-29 |  |  |  |
| 5 | 5 | Namensstrategie |  | 6d | 2017-05-29 | 2017-06-06 | 4 |  |  |
| 6 | 6 | Entscheidung2 (Webmeeting) | milestone | 0d | 2017-06-07 | 2017-06-07 |  |  |  |
| 7 | 7 | **Logoentwicklung und -umsetzung** |  | 12d | 2017-06-19 | 2017-07-04 | 6 | start no earlier than 2017-06-19 | Nina Sachs; Karin Janwlecke; Thorsten Huhn |
| 8 | 7.1 | Vorabentwürfe Logo |  | 7d | 2017-06-19 | 2017-06-27 |  |  | Nina Sachs; Karin Janwlecke; Thorsten Huhn |
| 9 | 7.2 | Entwürfe an Kunden |  | 5d | 2017-06-28 | 2017-07-04 | 8 |  | Nina Sachs; Thorsten Huhn; Patrick Redlich; Thomas Zehetbauer |
| 10 | 8 | Mock-Ups Website |  | 7d | 2017-05-29 | 2017-06-07 |  |  | Nina Sachs; Karin Janwlecke; Thorsten Huhn |
| 11 | 9 | Entscheidung 3 (Webmeeting) | milestone | 0d | 2017-06-14 | 2017-06-14 |  |  |  |
| 12 | 10 | Mock-Ups an Kunden |  | 4d | 2017-06-08 | 2017-06-13 | 10 |  | Nina Sachs; Karin Janwlecke; Thorsten Huhn; Patrick Redlich; Thomas Zehetbauer |
| 13 | 11 | Inhalte Styleguide abfragen |  | 3d | 2017-06-28 | 2017-06-30 |  |  | Nina Sachs |
| 14 | 12 | Entscheidung 3 | milestone | 0d | 2017-07-04 | 2017-07-04 |  |  |  |
| 15 | 13 | Fotoshooting |  | 1d | 2017-06-14 | 2017-06-14 | 12 |  |  |
| 16 | 14 | Entwicklen eines Styleguides |  | 10d | 2017-07-03 | 2017-07-14 | 13 |  | Nina Sachs; Karin Janwlecke |
| 17 | 15 | Erstellung Internetpräsenz |  | 30d | 2017-06-14 | 2017-07-26 | 12 |  | Nina Sachs; Thorsten Huhn; Patrick Redlich |
| 18 | 16 | Textleistungen Website |  | 15d | 2017-07-04 | 2017-07-24 |  |  | Nina Sachs; Thorsten Huhn; Patrick Redlich; Thomas Zehetbauer |
| 19 | 17 | Erstellung Facebook Fanpage |  | 10d | 2017-07-27 | 2017-08-09 | 17 |  | Nina Sachs; Thorsten Huhn |

Notes:
- 4: Schriften: Kalam und Athiti festgelegt / Unternehmensmission: / Zehetbauer&Sendlbeck ist ein verlässlicher und attraktiver Arbeitgeber in der Region, der / versteht, dass jeder Einzelne zum Erfolg des Unternehmens beiträgt. Dafür bieten wir Sicherheit, / Freiheit im Handeln und Teamgeist und glauben an die Identifikation aller Mitarbeiter / mit unserem Unternehmen. / Diese Überzeugung teilen wir auch mit unseren Kunden, haben immer ein offenes Ohr und / binden sie in unsere Prozesse ein. Wir verstehen uns als Partner und bieten genau die / Leistungen, die jeder einzelne Zahnarzt von uns erwartet, zuverlässig, vorausschauend und / pro-aktiv. / Wir wollen auch in Zukunft unabhängig sein, flexibel bleiben sowie hohe technische und / soziale Kompetenz beweisen.
- 6: Protokoll Webmeeting 06.06.2017 / Zehetbauer & Sendlbeck Dentallabor GmbH / Teilnehmer: / Patrick Redlich, Thomas Zehetbauer, Thorsten Huhn, Nina Sachs / Protokollant: / Nina Sachs / TOP´S: / TOP 1: Finale Farben / TOP 2: Finale Unternehmensmission / TOP 3: Namensvorschläge / TOP 4: Nächstes Webmeeting / TOP 5: Sonstiges / Entscheidungen: / TOP 1: Finale Farben / Die Tendenz geht zu Vorschlag 2, da dieser wärmer und femininer ist. In der weiteren Umsetzung werden jedoch beide Vorschläge berücksichtigt, z.B: in Form von Farbvarianten des Logos und der Mock-Ups für die Website. / TOP 2: Finale Unternehmensmission / Die finale Unternehmensmission bedarf keiner Änderungen mehr und ist somit einstimmig beschlossen. / TOP 3:Namensvorschläge / Die finalen 7 Namensvorschläge zur Vorlage im familiären, freundschaftlichen und kollegialen Umfeld werden diesem Dokument beigefügt. / Die genannten Vorschläge sollen bitte innerhalb der nächsten 7 Tage Kollegen, Freunden und Familie vorgelegt werden, sodass diese ihre Assoziationen zu den Vorschlägen kundtun können. / TOP 4: Nächstes Webmeeting / Mittwoch, den 14.06.2017 um 14:30Uhr / TOP 5: Sonstiges / Thorsten muss Patrick und Thomas ein Bier ausgeben ;)
- 11: TOP 1: Namensvorschläge / Smilein / Smilecreate / Raum & Zeit / Teamzahn / Mydentallabor / Raum & Zahn / Teamdenta / TOP 2: MockUps Website / TOP 3: Logo
